# Commercial Construction

Schedule from MS Project, 2016-08-22 to 2017-05-26, costs in $.

## Calendars

- Standard: Mon-Fri 08:00-12:00, 13:00-17:00; Sat-Sun off. Exceptions (off unless hours are given): 2016-12-24 to 2016-12-27 (Christmas), 2017-01-01 to 2017-01-02 (New Year), 2017-05-01 (International Workers' Day).
- End of Week: Mon-Thu off; Fri 08:00-12:00, 13:00-17:00; Sat-Sun off. Exceptions (off unless hours are given): 2016-12-24 to 2016-12-27 (Christmas), 2017-01-01 to 2017-01-02 (New Year), 2017-05-01 (International Workers' Day).

## Resources

| Resource | Unit | Rate | Cost per use |
| --- | --- | --- | --- |
| G.C. General Management |  | 60 |  |
| Elevator Contractor Management |  | 50 |  |
| Plumbing Contractor Management |  | 50 |  |
| Electric Contractor Management |  | 50 |  |
| Roofing Contractor Management |  | 50 |  |
| G.C. Project Management |  | 50 |  |
| Steel Erection Contractor Management |  | 50 |  |
| Concrete | ton | 500 | 100 |
| Painting Material | liter | 5 |  |
| HVAC Contractor Management |  | 50 |  |
| Electric Contractor |  | 40 |  |
| Plumbing Contractor |  | 40 |  |
| G.C. Survey Crew |  | 30 |  |
| Site Grading Contractor |  | 40 |  |
| G.C. Rough Carpenter Crew |  | 30 |  |
| G.C. Concrete Crew |  | 30 |  |
| G.C. Labor Crew |  | 30 |  |
| Elevator Contractor |  | 40 |  |
| G.C. Finish Carpenter Crew |  | 30 |  |
| HVAC Contractor |  | 40 |  |
| Drywall Contractor |  | 40 |  |
| Painting Contractor |  | 40 |  |
| Carpet Contractor |  | 40 |  |
| Landscape Contractor |  | 40 |  |
| Tile Contractor |  | 40 |  |
| G.C. Superintendent |  | 30 |  |
| G.C Scheduler |  | 35 |  |
| G.C Procurement |  | 35 |  |
| Steel Erection Contractor |  | 40 |  |
| Paving Contractor |  | 40 |  |
| G.C Accounting |  | 45 |  |

## Schedule

| ID | WBS | Task | Type | Duration | Start | Finish | Predecessors | Total slack | Free slack | Calendar | Resources | Work | Cost |
| --- | --- | --- | --- | --- | --- | --- | --- | --- | --- | --- | --- | --- | --- |
| 1 | 1 | **General Conditions** |  | 24.75d | 2016-08-22 | 2016-09-23 |  | 34.88d | 0d |  |  | 176h | 8,100 |
| 2 | 1.1 | Receive notice to proceed and sign contract |  | 3d | 2016-08-22 | 2016-08-24 |  | 164.62d | 0d |  | G.C. General Management | 24h | 1,440 |
| 3 | 1.2 | Submit bond and insurance documents |  | 2d | 2016-08-25 | 2016-08-26 | 2 | 164.62d | 0d |  | G.C. Project Management; G.C. General Management [25%] | 20h | 1,040 |
| 4 | 1.3 | Prepare and submit project schedule |  | 2d | 2016-08-29 | 2016-08-30 | 3 | 164.62d | 0d |  | G.C. Project Management [25%]; G.C Scheduler | 20h | 760 |
| 5 | 1.4 | Obtain building permits |  | 4d | 2016-08-31 | 2016-09-05 | 4 | 164.62d | 0d |  | G.C. Project Management [50%]; G.C Procurement [50%] | 32h | 1,360 |
| 6 | 1.5 | Submit preliminary shop drawings |  | 2w | 2016-09-06 | 2016-09-19 | 5 | 164.62d | 0d |  | G.C. Project Management [50%]; G.C Procurement [50%] | 80h | 3,400 |
| 7 | 1.6 | Submit monthly requests for payment |  | 6h | 2016-09-23 | 2016-09-23 | 6 | 34.88d | 0d | End of Week |  |  | 100 |
| 8 | 1.7 | Final General Condition | milestone | 0d | 2016-09-23 | 2016-09-23 | 7 | 170.88d | 0d |  |  |  |  |
| 9 | 2 | **Long Lead Procurement** |  | 26.25d | 2016-09-09 | 2016-10-17 |  | 120.88d | 0d |  |  | 320h | 15,200 |
| 10 | 2.1 | Submit shop drawings and order long lead items - steel |  | 2w | 2016-09-09 | 2016-09-23 | 7FF | 120.88d | 0d |  | Steel Erection Contractor Management | 80h | 4,000 |
| 11 | 2.2 | Submit shop drawings and order long lead items - roofing |  | 2w | 2016-09-20 | 2016-10-03 | 6 | 164.62d | 0d |  | Roofing Contractor Management | 80h | 4,000 |
| 12 | 2.3 | Detail, fabricate and deliver steel |  | 4w | 2016-09-20 | 2016-10-17 | 11SS | 154.62d | 0d |  | Steel Erection Contractor Management [50%]; Steel Erection Contractor [50%] | 160h | 7,200 |
| 13 | 2.4 | Long Lead Procurement check all items | milestone | 0d | 2016-10-17 | 2016-10-17 | 12 | 154.62d | 0d |  |  |  |  |
| 14 | 2 | **Mobilize on Site** |  | 10.25d | 2016-09-23 | 2016-10-07 |  | 118.12d | 0d |  |  | 64h | 2,280 |
| 15 | 2.1 | Install temporary power |  | 2.5d | 2016-09-23 | 2016-09-28 | 10 | 120.88d | 0d |  | Electric Contractor | 20h | 800 |
| 16 | 2.2 | Set up site office |  | 3d | 2016-09-28 | 2016-10-03 | 15 | 120.88d | 0d |  | G.C. Superintendent; G.C. Labor Crew [10%] | 26.4h | 792 |
| 17 | 2.3 | Prepare site - lay down yard and temporary fencing |  | 2d | 2016-10-06 | 2016-10-07 | 16 | 118.12d | 0d |  | Site Grading Contractor; G.C. Labor Crew [10%] | 17.6h | 688 |
| 18 | 2.4 | Finish temporay utilities | milestone | 0d | 2016-10-07 | 2016-10-07 | 17 | 160.62d | 0d |  |  |  |  |
| 19 | 3 | **Site Grading and Utilities** |  | 28d | 2016-10-10 | 2016-11-16 |  | 118.12d | 0d |  |  | 224h | 8,960 |
| 20 | 3.1 | Clear and grub site |  | 3d | 2016-10-10 | 2016-10-12 | 16, 17 | 118.12d | 0d |  | Site Grading Contractor | 24h | 960 |
| 21 | 3.2 | Rough grade site (cut and fill) |  | 1w | 2016-10-13 | 2016-10-19 | 17, 20 | 118.12d | 0d |  | Site Grading Contractor | 40h | 1,600 |
| 22 | 3.3 | Install exterior fire line and building fire riser |  | 2w | 2016-10-20 | 2016-11-02 | 21 | 118.12d | 0d |  | Plumbing Contractor | 80h | 3,200 |
| 23 | 3.4 | Perform final site grading |  | 2w | 2016-11-03 | 2016-11-16 | 22 | 118.12d | 0d |  | Site Grading Contractor | 80h | 3,200 |
| 24 | 3.5 | Install Utilities check | milestone | 0d | 2016-11-16 | 2016-11-16 | 23 | 118.12d | 0d |  |  |  |  |

| ID | WBS | Task | Type | Duration | Start | Finish | Predecessors | Total slack | Free slack | Constraint | Deadline | Resources | Work | Cost |
| --- | --- | --- | --- | --- | --- | --- | --- | --- | --- | --- | --- | --- | --- | --- |
| 25 | 4 | **Team meeting and discussion with partners** |  | 20.25d | 2017-01-04 | 2017-02-01 |  | 81.38d | 0d |  |  |  |  |  |
| 26 | 4.1 | Team meeting and discussion with partners 1 |  | 2h | 2017-01-04 | 2017-01-04 |  | 101.38d | 0d | start no earlier than 2017-01-04 |  |  |  |  |
| 27 | 4.2 | Team meeting and discussion with partners 2 |  | 2h | 2017-01-18 | 2017-01-18 |  | 91.38d | 0d | start no earlier than 2017-01-18 |  |  |  |  |
| 28 | 4.3 | Team meeting and discussion with partners 3 |  | 2h | 2017-02-01 | 2017-02-01 |  | 81.38d | 0d | start no earlier than 2017-02-01 |  |  |  |  |
| 29 | 5 | **Foundations** |  | 19.5d | 2016-11-17 | 2016-12-14 |  | 113.12d | 0d |  |  |  | 270.4h | 9,752 |
| 30 | 5.1 | Excavate foundations |  | 2w | 2016-11-17 | 2016-11-30 | 24 | 118.12d | 0d |  | 2016-12-20 | G.C. Labor Crew; Site Grading Contractor [50%] | 120h | 4,000 |
| 31 | 5.2 | Rough-in electric and plumbing in elevator |  | 4d | 2016-11-17 | 2016-11-22 | 30SS | 122.12d | 0d |  |  | Plumbing Contractor; Electric Contractor | 64h | 2,560 |
| 32 | 5.3 | Pour column piers and foundations |  | 5d | 2016-11-23 | 2016-11-29 | 31 | 122.12d | 0d |  | 2016-11-14 | G.C. Concrete Crew [150%] | 60h | 1,800 |
| 33 | 5.4 | Pour concrete elevator walls |  | 1.5d | 2016-11-30 | 2016-12-01 | 31, 32 | 122.12d | 0d |  |  | G.C. Concrete Crew; Concrete [1 ton] | 12h | 960 |
| 34 | 5.5 | Cure elevator wall concrete |  | 1d | 2016-12-01 | 2016-12-01 | 30, 33FF | 118.12d | 0d |  |  | G.C. Labor Crew [10%] | 0.8h | 24 |
| 35 | 6.4 | Strip wall forms |  | 2d | 2016-12-09 | 2016-12-12 | 34FS+5d | 113.12d | 0d |  |  | G.C. Labor Crew [10%] | 1.6h | 48 |
| 36 | 5.6 | Prepare and pour concrete floor in elevator pit |  | 12h | 2016-12-13 | 2016-12-14 | 35 | 113.12d | 0d |  |  | G.C. Concrete Crew | 12h | 360 |
| 37 | 5.7 | Foundation inspection | milestone | 0d | 2016-12-14 | 2016-12-14 | 36 | 113.12d | 0d |  |  |  |  |  |
| 38 | 6 | **Building Finishes** |  | 105d | 2016-12-14 | 2017-05-16 |  | 0d |  |  |  |  | 740h | 28,405 |
| 39 | 6.1 | Install millwork and wood trim |  | 3w | 2016-12-14 | 2017-01-09 | 37SS | 1d | 0d |  |  | G.C. Finish Carpenter Crew | 120h | 3,600 |
| 40 | 6.2 | Paint walls and woodwork |  | 1mo | 2017-01-10 | 2017-02-10 | 39 | 0.5d | 0d |  |  | Painting Contractor; Painting Material [1 liter] | 160h | 6,405 |
| 41 | 6.3 | Install conduit at ceiling plenum space |  | 2.5w | 2017-02-13 | 2017-03-01 | 40 | 0.5d | 0d |  |  | Electric Contractor | 100h | 4,000 |
| 42 | 6.5 | Install duct in ceiling plenum space |  | 3w | 2017-03-01 | 2017-03-21 | 41FS-4h | 0d |  |  |  | HVAC Contractor | 120h | 4,800 |
| 43 | 6.6 | Install ceiling grid |  | 2w | 2017-03-22 | 2017-04-10 | 42 | 0d |  |  |  | Drywall Contractor | 80h | 3,200 |
| 44 | 6.7 | Install ceiling tile |  | 2w | 2017-04-10 | 2017-04-27 | 43 | 0d |  |  |  | Drywall Contractor | 80h | 3,200 |
| 45 | 6.8 | Hang wallpaper |  | 2w | 2017-04-27 | 2017-05-16 | 44 | 0d |  |  |  | Painting Contractor | 80h | 3,200 |
| 46 | 6.9 | Building Finishes inspection | milestone | 0d | 2017-05-16 | 2017-05-16 | 45 | 0d |  |  |  |  |  |  |
| 47 | 7 | **Final Clean-up and Occupancy** |  | 6d | 2017-05-16 | 2017-05-24 |  | 0d |  |  |  |  | 52h | 2,000 |
| 48 | 7.1 | Install hard tile flooring in common areas |  | 1w | 2017-05-16 | 2017-05-22 | 46 | 0d |  |  |  | Tile Contractor | 40h | 1,600 |
| 49 | 7.2 | Remove debris from building and do final clean-up |  | 1d | 2017-05-22 | 2017-05-23 | 48 | 0d |  |  |  | Tile Contractor [50%] | 4h | 160 |
| 50 | 7.3 | Substantial completion date |  | 1d | 2017-05-23 | 2017-05-24 | 49 | 2.12d | 0d |  |  | G.C. Superintendent | 8h | 240 |

| ID | WBS | Task | Duration | Start | Finish | Predecessors | Total slack | Free slack | Constraint | Resources | Work | Cost |
| --- | --- | --- | --- | --- | --- | --- | --- | --- | --- | --- | --- | --- |
| 51 | 8 | **Complete Final Inspections** | 1.31d | 2017-05-23 | 2017-05-24 |  | 0d |  |  |  | 10.5h | 420 |
| 52 | 8.1 | Complete elevator inspection and certification | 0.5d | 2017-05-23 | 2017-05-23 | 49 | 0d |  |  | Elevator Contractor | 4h | 160 |
| 53 | 8.2 | Perform architect's inspection | 5h | 2017-05-24 | 2017-05-24 | 52 | 0d |  |  | G.C. Superintendent [50%]; G.C. Project Management [50%] | 5h | 200 |
| 54 | 8.3 | Perform Fire Marshal's inspection | 90min | 2017-05-24 | 2017-05-24 | 53 | 0.81d | 0d |  | G.C. Superintendent [50%]; G.C. Project Management [50%] | 1.5h | 60 |
| 55 | 9 | Issue final completion documents including warranties | 1d | 2017-05-24 | 2017-05-25 | 53 | 0d |  | start no earlier than 2017-01-09 | G.C. Project Management | 8h | 400 |
| 56 | 10 | Issue final request for payment | 1d | 2017-05-25 | 2017-05-26 | 54, 55 | 0d |  |  | G.C. Project Management [33%]; G.C Accounting [33%]; G.C. General Management [33%] | 7.92h | 409.2 |
